# CRONOGRAMA GENERAL

Schedule from MS Project, 2020-09-01 to 2021-01-28, costs in S/..
www.intercambiosvirtuales.org

## Calendars

- Estándar: Mon-Sun 08:00-13:00, 14:00-17:00.

## Schedule

| ID | WBS | Task | Type | Duration | Start | Finish | Predecessors | Total slack | Free slack | Constraint | Cost | Text1 |
| --- | --- | --- | --- | --- | --- | --- | --- | --- | --- | --- | --- | --- |
| 2 | 1 | **"REHABILITACION DEL LOCAL DE LA INSTITUCION EDUCATIVA N° 20001 - CASERIO DE LAS VEGAS DE CIENEGUILLO SUR-DISTRITO PIURA-PROVINCIA PIURA- REGION GRAU"** |  | 150d | 2020-09-01 | 2021-01-28 |  | 0d |  |  | 2,481,124.25 |  |
| 3 | 1.1 | INICIO | milestone | 0d | 2020-09-01 | 2020-09-01 |  | 2d |  |  |  |  |
| 4 | 1.2 | **ESTRUCTURAS** |  | 147d | 2020-09-01 | 2021-01-25 |  | 0d |  |  | 1,162,088.13 | 01 |
| 5 | 1.2.1 | **OBRAS PROVISIONALES** |  | 2d | 2020-09-03 | 2020-09-04 |  | 0d |  |  | 49,740.76 | 01.01 |
| 6 | 1.2.1.1 | OBRAS PROVISIONALES |  | 2d | 2020-09-03 | 2020-09-04 | 3, 38 | 0d |  | start no earlier than 2020-09-01 | 49,740.76 | 01.01 |
| 7 | 1.2.2 | **TRABAJOS PRELIMINARES** |  | 143d | 2020-09-05 | 2021-01-25 |  | 0d |  |  | 34,495.24 | 01.02 |
| 8 | 1.2.2.1 | TRAZO Y REPLANTEO |  | 140d | 2020-09-08 | 2021-01-25 | 6SS+5d | 3d |  | start no earlier than 2020-09-01 | 6,508.57 | 01.02.01 |
| 9 | 1.2.2.2 | DESMONTAJES |  | 10d | 2020-09-05 | 2020-09-14 | 6 | 0d |  | start no earlier than 2020-09-01 | 15,605.97 | 01.02.02 |
| 10 | 1.2.2.3 | DEMOLICION, REMOCION Y RASQUETEO |  | 5d | 2020-09-15 | 2020-09-19 | 9 | 0d |  | start no earlier than 2020-09-01 | 10,718.57 | 01.02.03 |
| 11 | 1.2.2.4 | DESMONTAJE DEL SISTEMA ELECTRICO |  | 3d | 2020-09-05 | 2020-09-07 | 9SS | 143d |  | start no earlier than 2020-09-01 | 1,662.13 | 01.02.04 |
| 12 | 1.2.3 | **MOVIMIENTO DE TIERRAS** |  | 47d | 2020-09-15 | 2020-10-31 |  | 0d |  |  | 171,288.65 | 01.03 |
| 13 | 1.2.3.1 | CORTE Y EXCAVACION |  | 20d | 2020-09-15 | 2020-10-04 | 10SS | 0d |  | start no earlier than 2020-09-01 | 42,661.79 | 01.03.01 |
| 14 | 1.2.3.2 | RELLENO |  | 15d | 2020-10-02 | 2020-10-16 | 15SS-5d | 0d |  | start no earlier than 2020-09-01 | 19,605.35 | 01.03.02 |
| 15 | 1.2.3.3 | MEJORAMIENTO DE TERRENO |  | 25d | 2020-10-07 | 2020-10-31 | 13FS+2d | 0d |  | start no earlier than 2020-09-01 | 54,962.02 | 01.03.04 |
| 16 | 1.2.3.4 | CONFORMACION,NIVELACION Y REFINE |  | 20d | 2020-09-20 | 2020-10-09 | 13SS+5d | 111d |  | start no earlier than 2020-09-01 | 10,144.11 | 01.03.03 |
| 17 | 1.2.3.5 | ACARREO Y ELIMINACION DE MATERIAL |  | 20d | 2020-10-05 | 2020-10-24 | 13 | 96d |  | start no earlier than 2020-09-01 | 43,915.38 | 01.03.05 |
| 18 | 1.2.4 | **CONCRETO SIMPLE** |  | 15d | 2020-10-17 | 2020-10-31 |  | 0d |  |  | 130,753.27 | 01.04 |
| 19 | 1.2.4.1 | SOLADO |  | 10d | 2020-10-17 | 2020-10-26 | 14 | 0d |  | start no earlier than 2020-09-01 | 8,106.01 | 01.04.01 |
| 20 | 1.2.4.2 | FALSO PISO |  | 10d | 2020-10-17 | 2020-10-26 | 14 | 34d | 0d | start no earlier than 2020-09-01 | 19,811.38 | 01.04.02 |
| 21 | 1.2.4.3 | CIMIENTO |  | 10d | 2020-10-22 | 2020-10-31 | 24SS | 0d |  | start no earlier than 2020-09-01 | 102,835.88 | 01.04.03 |
| 22 | 1.2.5 | **CONCRETO ARMADO** |  | 78d | 2020-10-22 | 2021-01-07 |  | 0d |  |  | 765,587.52 | 01.05 |
| 23 | 1.2.5.1 | SOBRECIMIENTO |  | 20d | 2020-10-30 | 2020-11-18 | 21FS-2d | 0d |  | start no earlier than 2020-09-01 | 110,054.63 | 01.05.01 |
| 24 | 1.2.5.2 | ZAPATAS |  | 20d | 2020-10-22 | 2020-11-10 | 19FS-5d | 0d |  | start no earlier than 2020-09-01 | 95,573.84 | 01.05.02 |
| 25 | 1.2.5.3 | VIGAS DE CIMENTACION |  | 30d | 2020-10-27 | 2020-11-25 | 24SS+5d | 64d |  | start no earlier than 2020-09-01 | 18,894.48 | 01.05.03 |
| 26 | 1.2.5.4 | COLUMNAS |  | 55d | 2020-10-27 | 2020-12-20 | 24SS+5d | 20d | 0d | start no earlier than 2020-09-01 | 180,999.18 | 01.05.04 |
| 27 | 1.2.5.5 | PLACAS |  | 55d | 2020-10-29 | 2020-12-22 | 26SS+2d | 37d |  | start no earlier than 2020-09-01 | 3,938.7 | 01.05.05 |
| 28 | 1.2.5.6 | VIGAS |  | 51d | 2020-11-06 | 2020-12-26 | 26SS+10d | 20d | 0d | start no earlier than 2020-09-01 | 117,376.01 | 01.05.06 |
| 29 | 1.2.5.7 | LOSAS ALIGERADAS |  | 40d | 2020-11-16 | 2020-12-25 | 28SS+10d | 20d | 0d | start no earlier than 2020-09-01 | 114,882.63 | 01.05.07 |
| 30 | 1.2.5.8 | COLUMNETAS Y SOLERAS |  | 40d | 2020-11-29 | 2021-01-07 | 43FS-20d | 21d |  | start no earlier than 2020-09-01 | 42,386.14 | 01.05.08 |
| 31 | 1.2.5.9 | LOSA MACISA |  | 30d | 2020-11-16 | 2020-12-15 | 29SS | 44d | 0d | start no earlier than 2020-09-01 | 7,112.43 | 01.05.09 |
| 32 | 1.2.5.10 | CUNETAS CON REJILLA |  | 5d | 2020-12-19 | 2020-12-23 | 33 | 36d |  | start no earlier than 2020-09-01 | 48,304.06 | 01.05.10 |
| 33 | 1.2.5.11 | BANCAS DE CONCRETO |  | 5d | 2020-12-14 | 2020-12-18 | 20, 44 | 36d | 0d | start no earlier than 2020-09-01 | 5,712.28 | 01.05.11 |
| 34 | 1.2.5.12 | CISTERNA |  | 7d | 2020-11-16 | 2020-11-22 | 26SS, 31SS | 55d | 0d | start no earlier than 2020-09-01 | 8,229.03 | 01.05.12 |
| 35 | 1.2.5.13 | TANQUE ELEVADO |  | 7d | 2020-11-16 | 2020-11-22 | 34SS | 67d | 0d | start no earlier than 2020-09-01 | 3,402.12 | 01.05.13 |
| 36 | 1.2.5.14 | POZO DE PERCOLACION Y TANQUE SEPTICO |  | 12d | 2020-11-23 | 2020-12-04 | 34 | 55d |  | start no earlier than 2020-09-01 | 8,721.99 | 01.06 |

| ID | WBS | Task | Duration | Start | Finish | Predecessors | Total slack | Free slack | Constraint | Cost | Text1 |
| --- | --- | --- | --- | --- | --- | --- | --- | --- | --- | --- | --- |
| 37 | 1.2.6 | **MOVILIZACION Y DESMOVILIZACION DE EQUIPO** | 2d | 2020-09-01 | 2020-09-02 |  | 0d |  |  | 4,653.52 | 01.08 |
| 38 | 1.2.6.1 | MOVILIZACION DE EQUIPO | 2d | 2020-09-01 | 2020-09-02 |  | 0d |  | start no earlier than 2020-09-01 | 4,653.52 | 01.08.01 |
| 39 | 1.2.7 | **MITIGACION AMBIENTAL** | 80d | 2020-10-15 | 2021-01-02 |  | 26d |  |  | 5,569.17 | 01.09 |
| 40 | 1.2.7.1 | RIEGO DE TERRENO, MATERIAL EXCAVADO Y AGREGADOS | 80d | 2020-10-15 | 2021-01-02 | 13FS+10d | 26d | 0d | start no earlier than 2020-09-01 | 4,265.6 | 01.09.01 |
| 41 | 1.2.7.2 | PREVENCION DE DAÑOS - DERRAME DE COMBUSTIBLES | 80d | 2020-10-15 | 2021-01-02 | 40SS | 26d |  | start no earlier than 2020-09-01 | 1,303.57 | 01.09.02 |
| 42 | 1.3 | **ARQUITECTURA** | 105d | 2020-10-10 | 2021-01-22 |  | 0d |  |  | 985,774.71 | 02 |
| 43 | 1.3.1 | MUROS Y TABIQUES DE ALBAÑILERIA | 70d | 2020-10-10 | 2020-12-18 | 23FS-40d | 0d |  | start no earlier than 2020-09-01 | 138,051.49 | 02.01 |
| 44 | 1.3.2 | REVOQUES Y REVESTIMIENTOS | 55d | 2020-10-20 | 2020-12-13 | 43SS+10d | 0d |  | start no earlier than 2020-09-01 | 146,212.95 | 02.02 |
| 45 | 1.3.3 | CIELORRASOS | 60d | 2020-10-20 | 2020-12-18 | 44SS | 41d |  | start no earlier than 2020-09-01 | 43,677.87 | 02.03 |
| 46 | 1.3.4 | PISOS Y PAVIMENTOS | 60d | 2020-10-27 | 2020-12-25 | 20 | 34d | 0d | start no earlier than 2020-09-01 | 155,706.27 | 02.04 |
| 47 | 1.3.5 | ZOCALOS Y CONTRAZOCALOS | 20d | 2020-11-29 | 2020-12-18 | 43FS-20d | 41d |  | start no earlier than 2020-09-01 | 34,787.75 | 02.05 |
| 48 | 1.3.6 | COBERTURAS | 25d | 2020-11-26 | 2020-12-20 | 29SS+10d | 20d | 0d | start no earlier than 2020-09-01 | 160,680.87 | 02.06 |
| 49 | 1.3.7 | CARPINTERIA DE MADERA | 20d | 2020-11-26 | 2020-12-15 | 48SS | 20d | 0d | start no earlier than 2020-09-01 | 49,547.82 | 02.07 |
| 50 | 1.3.8 | CARPINTERIA METALICA Y HERRERÍA | 30d | 2020-11-26 | 2020-12-25 | 49SS | 20d | 0d | start no earlier than 2020-09-01 | 38,543.11 | 02.08 |
| 51 | 1.3.9 | VENTANAS, PUERTAS, MAMPARAS Y MUROS CORTINA DE ALUMINIO CON PROTECTOR, CRISTAL Y VIDRIOS | 25d | 2020-12-20 | 2021-01-13 | 44FS+6d | 15d |  | start no earlier than 2020-09-01 | 122,967.67 | 02.09 |
| 52 | 1.3.10 | CERRAJERIA | 39d | 2020-12-01 | 2021-01-08 | 50FS-25d | 20d |  | start no earlier than 2020-09-01 | 5,471.01 | 02.10 |
| 53 | 1.3.11 | PINTURA | 35d | 2020-12-10 | 2021-01-13 | 44FS-4d | 15d |  | start no earlier than 2020-09-01 | 65,478.56 | 02.11 |
| 54 | 1.3.12 | JUNTAS | 10d | 2020-12-16 | 2020-12-25 | 46FS-10d | 34d |  | start no earlier than 2020-09-01 | 8,158.88 | 02.12 |
| 55 | 1.3.13 | VARIOS | 100d | 2020-10-15 | 2021-01-22 | 6SS+11d | 6d |  | start no earlier than 2020-10-15 | 16,490.46 | 02.13 |
| 56 | 1.4 | **INSTALACIONES SANITARIAS** | 110d | 2020-09-17 | 2021-01-04 |  | 24d |  |  | 86,482.32 | 03 |
| 57 | 1.4.1 | MOVIMIENTO DE TIERRAS | 5d | 2020-09-17 | 2020-09-21 | 69SS, 13SS+2d | 129d |  | start no earlier than 2020-09-01 | 14,468 | 03.01 |
| 58 | 1.4.2 | SISTEMA DE AGUA POTABLE EXTERIOR | 10d | 2020-11-01 | 2020-11-10 | 64 | 64d | 0d | start no earlier than 2020-09-01 | 6,612.93 | 03.02 |
| 59 | 1.4.3 | SISTEMA DE RIEGO | 3d | 2020-11-11 | 2020-11-13 | 58 | 76d |  | start no earlier than 2020-09-01 | 991.53 | 03.03 |
| 60 | 1.4.4 | SISTEMA DE DESAGUE EXTERIOR | 10d | 2020-11-11 | 2020-11-20 | 58 | 64d | 0d | start no earlier than 2020-09-01 | 8,730.83 | 03.04 |
| 61 | 1.4.5 | PRUEBA HIDRAULICA DE CISTERNA, TANQUE Y SISTEMA DE BOMBEO | 3d | 2020-11-21 | 2020-11-23 | 60 | 64d | 0d | start no earlier than 2020-09-01 | 722.15 | 03.05 |
| 62 | 1.4.6 | APARATOS SANITARIOS Y ACCESORIOS | 5d | 2020-11-16 | 2020-11-20 | 58SF, 60SF+10d | 69d |  | start no earlier than 2020-09-01 | 17,319.52 | 03.06 |
| 63 | 1.4.7 | INSTALACIONES SANITARIAS DE DESAGUE | 10d | 2020-10-12 | 2020-10-21 | 14SS+10d | 64d | 0d | start no earlier than 2020-09-01 | 9,308.78 | 03.07 |
| 64 | 1.4.8 | INSTALACIONES SANITARIAS DE AGUA | 10d | 2020-10-22 | 2020-10-31 | 63 | 64d | 0d | start no earlier than 2020-09-01 | 6,589.69 | 03.08 |
| 65 | 1.4.9 | TUBERIAS Y ACCESORIOS TANQUE ELEVADO | 2d | 2020-11-18 | 2020-11-19 | 35SS+2d | 70d |  | start no earlier than 2020-09-01 | 10,176.49 | 03.09 |
| 66 | 1.4.10 | SISTEMA DE DRENAJE PLUVIAL | 5d | 2020-12-31 | 2021-01-04 | 29FS+5d | 24d |  | start no earlier than 2020-09-01 | 11,030.02 | 03.10 |
| 67 | 1.4.11 | RECONEXION A LAS REDES EXISTENTES | 2d | 2020-11-24 | 2020-11-25 | 61 | 64d |  | start no earlier than 2020-09-01 | 532.38 | 03.11 |

| ID | WBS | Task | Type | Duration | Start | Finish | Predecessors | Total slack | Free slack | Constraint | Cost | Text1 |
| --- | --- | --- | --- | --- | --- | --- | --- | --- | --- | --- | --- | --- |
| 68 | 1.5 | **INSTALACIONES ELECTRICAS** |  | 126d | 2020-09-15 | 2021-01-18 |  | 10d |  |  | 197,566.76 | 04 |
| 69 | 1.5.1 | MOVIMIENTO DE TIERRAS |  | 6d | 2020-09-15 | 2020-09-20 | 13SS | 130d | 2d | start no earlier than 2020-09-01 | 20,760.42 | 04.01 |
| 70 | 1.5.2 | CONDUCTORES, DUCTOS Y ACCESORIOS |  | 10d | 2020-12-23 | 2021-01-01 | 72 | 24d | 3d | start no earlier than 2020-09-01 | 58,705.32 | 04.02 |
| 71 | 1.5.3 | ARTEFACTOS DE ILUMINACION - LUMINARIAS / TOMACORRIENTES |  | 3d | 2021-01-05 | 2021-01-07 | 76FS+10d, 70 | 21d |  | start no earlier than 2020-09-01 | 50,936.24 | 04.03 |
| 72 | 1.5.4 | TABLERO ELECTRICO TRIFASICO/ MONOFASICO |  | 4d | 2020-12-19 | 2020-12-22 | 44FS+5d | 0d |  | start no earlier than 2020-09-01 | 5,905.4 | 04.04 |
| 73 | 1.5.5 | INTERRUPTORES TERMOMAGNETICOS TRIFASICOS |  | 2d | 2020-12-18 | 2020-12-19 | 72SS-1d | 21d | 0d | start no earlier than 2020-09-01 | 746.07 | 04.05 |
| 74 | 1.5.6 | INTERRUPTORES TERMOMAGNETICOS MONOFASICOS |  | 2d | 2020-12-18 | 2020-12-19 | 73SS | 21d | 0d | start no earlier than 2020-09-01 | 3,233.68 | 04.06 |
| 75 | 1.5.7 | INTERRUPTORES DIFERENCIALES |  | 3d | 2020-12-18 | 2020-12-20 | 74SS | 21d | 2d | start no earlier than 2020-09-01 | 4,035.78 | 04.07 |
| 76 | 1.5.8 | CIRCUITOS DE MANDOS DE ILUMINACION DE PATIOS |  | 3d | 2020-12-23 | 2020-12-25 | 72, 75 | 19d | 0d | start no earlier than 2020-09-01 | 1,644.55 | 04.08 |
| 77 | 1.5.9 | POSTES DE F°G° |  | 3d | 2020-12-18 | 2020-12-20 | 72FS-5d | 0d |  | start no earlier than 2020-09-01 | 26,611.74 | 04.09 |
| 78 | 1.5.10 | PUESTA A TIERRA DE TABLERO GENERAL |  | 3d | 2020-12-23 | 2020-12-25 | 72 | 34d |  | start no earlier than 2020-09-01 | 1,762.2 | 04.10 |
| 79 | 1.5.11 | BUZON ELECTRICO |  | 4d | 2020-12-18 | 2020-12-21 | 77SS | 38d |  | start no earlier than 2020-09-01 | 712.74 | 04.11 |
| 80 | 1.5.12 | ELECTROBOMBA |  | 2d | 2020-12-26 | 2020-12-27 | 76 | 19d | 0d | start no earlier than 2020-09-01 | 397.46 | 04.12 |
| 81 | 1.5.13 | EQUIPOS DE CLIMATIZACION |  | 4d | 2021-01-02 | 2021-01-05 | 80FS+5d | 19d | 0d | start no earlier than 2020-09-01 | 11,762.1 | 04.13 |
| 82 | 1.5.14 | TRANSPORTE DE MATERIALES |  | 2d | 2021-01-06 | 2021-01-07 | 81 | 19d | 0d | start no earlier than 2020-09-01 | 4,645.56 | 04.14 |
| 83 | 1.5.15 | COMUNICACIONES |  | 2d | 2021-01-08 | 2021-01-09 | 82 | 19d |  | start no earlier than 2020-09-01 | 3,502.26 | 04.15 |
| 84 | 1.5.16 | INSTALACION DE GAS |  | 2d | 2020-12-17 | 2020-12-18 | 72SS-2d | 41d |  | start no earlier than 2020-09-01 | 684.64 | 04.16 |
| 85 | 1.5.17 | CONEXION Y ADECUACION A RED DE ENERGIA EXISTENTE |  | 4d | 2021-01-15 | 2021-01-18 | 77FS+25d | 0d |  | start no earlier than 2020-09-01 | 1,520.6 | 04.17 |
| 86 | 1.6 | **MOBILIARIO** |  | 10d | 2021-01-19 | 2021-01-28 |  | 0d |  |  | 49,212.33 | 05 |
| 87 | 1.6.1 | MOBILIARIO |  | 10d | 2021-01-19 | 2021-01-28 | 44FS+5d, 85 | 0d |  | start no earlier than 2020-09-01 | 34,772.82 | 05.01 |
| 88 | 1.6.2 | EQUIPAMIENTO (COMPUTADORAS Y EQUIPOS) |  | 10d | 2021-01-19 | 2021-01-28 | 87SS | 0d |  | start no earlier than 2020-09-01 | 14,439.51 | 05.02 |
| 89 | 1.6.3 | FIN | milestone | 0d | 2021-01-28 | 2021-01-28 | 88 | 0d |  | start no earlier than 2020-09-01 |  |  |
